# REGNET02

Schedule from MS Project, 2001-04-02 to 2001-10-02.
Cultural Heritage & E-Commerce
AIT

## Calendars

- Standard: Mon-Fri 08:00-12:00, 13:00-17:00; Sat-Sun off.

## Schedule

| ID | WBS | Task | Type | Duration | Start | Finish | Predecessors | Baseline start | Baseline finish | Baseline duration | Total slack | Free slack | Constraint | Deadline |
| --- | --- | --- | --- | --- | --- | --- | --- | --- | --- | --- | --- | --- | --- | --- |
| 1 | 1 | **WP-1 Analysis of the State of the Art and Development of Concepts** |  | 131d? | 2001-04-02 | 2001-10-01 |  | 2001-01-01 | 2001-06-29 | 130d | 1d |  |  |  |
| 2 | 1.1 | T1.1 Definition of content to be provided |  | 65d | 2001-04-03 | 2001-07-02 |  | 2001-01-01 | 2001-06-29 | 130d | 0d |  | start no earlier than 2001-04-02 |  |
| 3 | 1.2 | T1.2 Development of a documentation and digitization plan for content reation and management |  | 65d | 2001-07-03 | 2001-10-01 | 2 | 2001-01-01 | 2001-01-01 | 1d | 0d |  | start no earlier than 2001-04-02 |  |
| 4 | 1.3 | T1.3 Identification of standards to be used |  | 43d | 2001-04-03 | 2001-05-31 |  | 2001-01-01 | 2001-01-01 | 1d | 88d |  | start no earlier than 2001-04-02 |  |
| 5 | 1.4 | **T1.4 Development of the System Specifications** |  | 130d? | 2001-04-02 | 2001-09-28 |  | 2001-01-01 | 2001-01-01 | 1d | 1d |  |  |  |
| 6 | 1.4.1 | **T1.4.1 - Node-1: Portal** |  | 108d? | 2001-05-02 | 2001-09-28 |  |  |  |  | 1d |  |  |  |
| 7 | 1.4.1.1 | T1.4.1.1 - Node-1: ~ Data Generation |  | 108d? | 2001-05-02 | 2001-09-28 |  |  |  |  | 1d |  | start no earlier than 2001-05-02 |  |
| 8 | 1.4.1.2 | T1.4.1.2 - Node-1: ~ Search System |  | 108d? | 2001-05-02 | 2001-09-28 |  |  |  |  | 1d |  | start no earlier than 2001-05-02 |  |
| 9 | 1.4.1.3 | T1.4.1.3 - Node-1: ~ eBusiness |  | 108d? | 2001-05-02 | 2001-09-28 |  |  |  |  | 1d |  | start no earlier than 2001-05-02 |  |
| 10 | 1.4.2 | **T1.4.2 - Node-2: CH-Data Management** |  | 108d? | 2001-05-02 | 2001-09-28 |  |  |  |  | 1d |  |  |  |
| 11 | 1.4.2.1 | T1.4.2.1 - Node-2: ~ Repository Management |  | 108d? | 2001-05-02 | 2001-09-28 |  |  |  |  | 1d |  | start no earlier than 2001-05-02 |  |
| 12 | 1.4.2.2 | T1.4.2.2 - Node-2: ~ Reference System |  | 108d? | 2001-05-02 | 2001-09-28 |  |  |  |  | 1d |  | start no earlier than 2001-05-02 |  |
| 13 | 1.4.3 | **T1.4.3 - Node-3: eBusiness-Data Management** |  | 108d? | 2001-05-02 | 2001-09-28 |  |  |  |  | 1d |  |  |  |
| 14 | 1.4.3.1 | T1.4.3.1 - Node-3: ~ Catalogue Management |  | 108d? | 2001-05-02 | 2001-09-28 |  |  |  |  | 1d |  | start no earlier than 2001-05-02 |  |
| 15 | 1.4.3.2 | T1.4.3.2 - Node-3: ~ Procurement & Delivery |  | 108d? | 2001-05-02 | 2001-09-28 |  |  |  |  | 1d |  | start no earlier than 2001-05-02 |  |
| 16 | 1.4.4 | **T1.4.4 - Node-4: Ontology Checker** |  | 108d? | 2001-05-02 | 2001-09-28 |  |  |  |  | 1d |  |  |  |
| 17 | 1.4.4.1 | T1.4.4.1 - Node-4: ~ Knowledge Base |  | 108d? | 2001-05-02 | 2001-09-28 |  |  |  |  | 1d |  | start no earlier than 2001-05-02 |  |
| 18 | 1.4.5 | **T1.4.5 - Node-5: Electronic Publisher** |  | 108d? | 2001-05-02 | 2001-09-28 |  |  |  |  | 1d |  |  |  |
| 19 | 1.4.5.1 | T1.4.5.1 - Node-5: Electronic Publisher |  | 108d? | 2001-05-02 | 2001-09-28 |  |  |  |  | 1d |  | start no earlier than 2001-05-02 |  |
| 20 | 1.4.6 | **T1.4.6 - REGNET - Core System** |  | 130d? | 2001-04-02 | 2001-09-28 |  |  |  |  | 1d |  |  |  |
| 21 | 1.4.6.1 | T1.4.6.1 - REGNET - Core System - Architecture |  | 130d? | 2001-04-02 | 2001-09-28 |  |  |  |  | 1d |  |  |  |
| 22 | 1.4.6.2 | T1.4.6.2 - REGNET - Core System - Interfaces |  | 130d? | 2001-04-02 | 2001-09-28 |  |  |  |  | 1d |  |  |  |
| 23 | 1.4.6.3 | T1.4.6.3 - REGNET - Core System - Platform |  | 130d? | 2001-04-02 | 2001-09-28 |  |  |  |  | 1d |  |  |  |
| 24 | 1.5 | T1.5 Setup of the Legal Framework and Partnership Model |  | 65d | 2001-07-03 | 2001-10-01 | 25 | 2001-01-01 | 2001-01-01 | 1d | 0d |  | start no earlier than 2001-04-02 |  |
| 25 | 1.6 | T1.6 Definition of supported Business Functions |  | 65d | 2001-04-03 | 2001-07-02 |  | 2001-01-01 | 2001-01-01 | 1d | 0d |  | start no earlier than 2001-04-02 |  |
| 26 | 1.7 | T1.7 Identification of Market (Segments) and User Groups |  | 130d | 2001-04-03 | 2001-10-01 |  | 2001-01-01 | 2001-01-01 | 1d | 0d |  | start no earlier than 2001-04-02 |  |
| 27 | 2 | M1-Milestone 1 | milestone | 1d | 2001-10-02 | 2001-10-02 | 3, 5, 24, 26 | 2001-07-02 | 2001-07-02 | 1d | 0d |  | start no earlier than 2001-09-24 |  |
| 28 | 3 | Kick-Off-Meeting |  | 2d | 2001-04-19 | 2001-04-20 |  |  |  |  | -14d | 0d | start no earlier than 2001-04-19 | 2001-04-02 |
